# Проведение комплекса мероприятий, направленных на освоение и адаптацию международных стандартов управления проектами, создание

Schedule from MS Project, 2012-01-12 to 2012-12-31, status date 2012-06-30, A marks actual dates.
ДЭРМС

## Calendars

- Стандартный: Mon-Fri 09:00-13:00, 14:00-18:00; Sat-Sun off. Exceptions (off unless hours are given): 2012-06-03 09:00-13:00, 14:00-18:00.

## Resources

| Resource |
| --- |
| Груздева И.В. |
| Бушуев А.В. |

## Schedule

| ID | WBS | Task | Duration | Start | Finish | Predecessors | Complete | Remaining | Total slack | Constraint | Text1 | Text5 | Text6 | Text7 |
| --- | --- | --- | --- | --- | --- | --- | --- | --- | --- | --- | --- | --- | --- | --- |
| 1 | 1 | **Областная целевая программа сохранения, возрождения и развития НХП в ЯО на 2012 -2014 годы** | 254d | 2012-01-12 A | 2012-12-31 |  | 78% | 55.62d | 0d |  | ܁) |  |  |  |
| 2 | 1.1 | **Задача 1. Информационно-аналитическое обеспечение развития отрасли НХП Ярославской области** | 254d | 2012-01-12 A | 2012-12-31 |  | 77% | 58.24d | 0d |  | ܁) | 300 |  |  |
| 3 | 1.1.1 | **Создание и формирование электронных реестров организаций и мастеров, занятых в сфере НХП, изделий НХП** | 219d | 2012-03-01 A | 2012-12-31 A |  | 100% |  |  |  | ܁) |  |  |  |
| 4 | 1.1.1.1 | Организация и проведение комисси по НХП | 16d | 2012-03-01 A | 2012-03-22 A |  | 100% |  |  | start no earlier than 2012-03-01 |  |  |  |  |
| 5 | 1.1.1.2 | Добавление новых записей в реестр | 5d | 2012-03-23 A | 2012-03-29 A | 4 | 100% |  |  |  |  |  |  |  |
| 6 | 1.1.1.3 | Организация и проведение комисси по НХП | 16d | 2012-06-01 A | 2012-06-21 A | 4FS+50d | 100% |  |  | start no earlier than 2012-03-01 |  |  |  |  |
| 7 | 1.1.1.4 | Добавление новых записей в реестр | 5d | 2012-06-22 A | 2012-06-28 A | 6 | 100% |  |  |  |  |  |  |  |
| 8 | 1.1.1.5 | Организация и проведение комисси по НХП | 16d | 2012-09-03 A | 2012-09-24 A | 6FS+51d | 100% |  |  | start no earlier than 2012-03-01 |  |  |  |  |
| 9 | 1.1.1.6 | Добавление новых записей в реестр | 5d | 2012-09-25 A | 2012-10-01 A | 8 | 100% |  |  |  |  |  |  |  |
| 10 | 1.1.1.7 | Организация и проведение комисси по НХП | 16d | 2012-12-03 A | 2012-12-24 A | 8FS+49d | 100% |  |  | start no earlier than 2012-03-01 |  |  |  |  |
| 11 | 1.1.1.8 | Добавление новых записей в реестр | 5d | 2012-12-25 A | 2012-12-31 A | 10 | 100% |  |  |  |  |  |  |  |
| 12 | 1.1.2 | **Развитие механизма и видов информирования организаций, индивидуальных предпринимателей и индивидуально работающих мастеров, занятых в сфере НХП** | 178d | 2012-01-12 A | 2012-09-14 A |  | 100% |  |  |  | ܁) | 150 | 150 |  |
| 13 | 1.1.2.1 | 1 Направление информации организациям через интернет-ресурсы, почтой и др. | 6d | 2012-01-12 A | 2012-01-19 A |  | 100% |  |  | finish no earlier than 2012-01-19 |  | да | да | нет |
| 14 | 1.1.2.2 | 2 Направление информации организациям через интернет-ресурсы, почтой и др. | 5d | 2012-03-12 A | 2012-03-16 A |  | 100% |  |  | finish no earlier than 2012-03-16 |  | да | да | нет |
| 15 | 1.1.2.3 | 3 Направление информации организациям через интернет-ресурсы, почтой и др. | 5d | 2012-06-11 A | 2012-06-15 A |  | 100% |  |  | finish no earlier than 2012-06-15 |  | да | да | нет |
| 16 | 1.1.2.4 | 4 Направление информации организациям через интернет-ресурсы, почтой и др. | 5d | 2012-09-10 A | 2012-09-14 A |  | 100% |  |  | finish no earlier than 2012-09-14 |  | да | да | нет |
| 17 | 1.1.3 | **Проведение ежегодного мониторинга состояния отрасли НХП Ярославской области** | 219d | 2012-03-01 A | 2012-12-31 A |  | 100% |  |  |  | ܁) | 27 | 27 |  |
| 18 | 1.1.3.1 | Направление запросов в организации | 16d | 2012-03-01 A | 2012-03-22 A |  | 100% |  |  | start no earlier than 2012-03-01 |  | да | да | нет |
| 19 | 1.1.3.2 | Обобщение ответов на запросы от организаций | 5d | 2012-03-23 A | 2012-03-29 A | 18 | 100% |  |  |  |  |  |  |  |
| 20 | 1.1.3.3 | Направление запросов в организации | 16d | 2012-06-01 A | 2012-06-21 A | 18FS+50d | 100% |  |  | start no earlier than 2012-03-01 |  | да | да | нет |
| 21 | 1.1.3.4 | Обобщение ответов на запросы от организаций | 5d | 2012-06-22 A | 2012-06-28 A | 20 | 100% |  |  |  |  |  |  |  |
| 22 | 1.1.3.5 | Направление запросов в организации | 16d | 2012-09-03 A | 2012-09-24 A | 20FS+51d | 100% |  |  | start no earlier than 2012-03-01 |  | да | да | нет |
| 23 | 1.1.3.6 | Обобщение ответов на запросы от организаций | 5d | 2012-09-25 A | 2012-10-01 A | 22 | 100% |  |  |  |  |  |  |  |
| 24 | 1.1.3.7 | Направление запросов в организации | 16d | 2012-12-03 A | 2012-12-24 A | 22FS+49d | 100% |  |  | start no earlier than 2012-03-01 |  | да | да | нет |
| 25 | 1.1.3.8 | Обобщение ответов на запросы от организаций | 5d | 2012-12-25 A | 2012-12-31 A | 24 | 100% |  |  |  |  |  |  |  |

Notes:
- 2: Text3: количество информированных организаций и ИП, в том числе по вопросам налогообложения и финанасовой поддержки
- 3: Text3: количество созданных реестров
- 4: Text3: Протокол заседания комиссии
- 5: Text3: актуализированные реестры
- 6: Text3: Протокол заседания комиссии
- 7: Text3: актуализированные реестры
- 8: Text3: Протокол заседания комиссии
- 9: Text3: актуализированные реестры
- 10: Text3: Протокол заседания комиссии
- 11: Text3: актуализированные реестры
- 12: Text3: количество информированных организаций, ИП
- 13: Text3: Информация направлена
- 14: Text3: Информация направлена
- 15: Text3: Информация направлена
- 16: Text3: Информация направлена
- 17: Text3: количество организаций и ИП охваченных мониторингом
- 18: Text3: направленные запросы
- 19: Text3: сводный отчет
- 20: Text3: направленные запросы
- 21: Text3: сводный отчет
- 22: Text3: направленные запросы
- 23: Text3: сводный отчет
- 24: Text3: направленные запросы
- 25: Text3: сводный отчет

| ID | WBS | Task | Duration | Start | Finish | Predecessors | Complete | Remaining | Total slack | Free slack | Constraint | Text1 | Text3 | Text5 | Text6 | Text7 |
| --- | --- | --- | --- | --- | --- | --- | --- | --- | --- | --- | --- | --- | --- | --- | --- | --- |
| 26 | 1.1.4 | **Обследование организаций сферы НХП и разработка стратегии сохранения и развития отрасли НХП в регионе** | 219d | 2012-03-01 A | 2012-12-31 A |  | 100% |  |  |  |  | ܁) | количество организаций и ИП охваченных обследованием | 17 | 17 |  |
| 27 | 1.1.4.1 | Направление запросов в организации | 16d | 2012-03-01 A | 2012-03-22 A |  | 100% |  |  |  | start no earlier than 2012-03-01 |  | направленные запросы | да | да | нет |
| 28 | 1.1.4.2 | Консультирование организаций в соответствии с итогами обследования | 5d | 2012-03-23 A | 2012-03-29 A | 27 | 100% |  |  |  |  |  | проведенные консультации | да | да | нет |
| 29 | 1.1.4.3 | Направление запросов в организации | 16d | 2012-06-01 A | 2012-06-21 A | 27FS+50d | 100% |  |  |  | start no earlier than 2012-03-01 |  | направленные запросы | да | да | нет |
| 30 | 1.1.4.4 | Консультирование организаций в соответствии с итогами обследования | 5d | 2012-06-22 A | 2012-06-28 A | 29 | 100% |  |  |  |  |  | сводный отчет | да | да | нет |
| 31 | 1.1.4.5 | Направление запросов в организации | 16d | 2012-09-03 A | 2012-09-24 A | 29FS+51d | 100% |  |  |  | start no earlier than 2012-03-01 |  | направленные запросы | да | да | нет |
| 32 | 1.1.4.6 | Консультирование организаций в соответствии с итогами обследования | 5d | 2012-09-25 A | 2012-10-01 A | 31 | 100% |  |  |  |  |  | сводный отчет | да | да | нет |
| 33 | 1.1.4.7 | Направление запросов в организации | 16d | 2012-12-03 A | 2012-12-24 A | 31FS+49d | 100% |  |  |  | start no earlier than 2012-03-01 |  | направленные запросы | да | да | нет |
| 34 | 1.1.4.8 | Консультирование организаций в соответствии с итогами обследования | 5d | 2012-12-25 A | 2012-12-31 A | 33 | 100% |  |  |  |  |  | сводный отчет | да | да | нет |
| 35 | 1.1.5 | **Обеспечение взаимодействия органов государственной власти и органов местного самоуправления муниципальных образований области с организациями и мастерами по вопросам поддержки НХП** | 11d | 2012-03-01 A | 2012-03-15 A |  | 100% |  |  |  |  | ܁) | количество проведенных семинаров, круглых столов и т.д. |  |  |  |
| 36 | 1.1.5.1 | Определение участников видеоконференции | 7d | 2012-03-01 A | 2012-03-09 A |  | 100% |  |  |  | finish no earlier than 2012-03-09 |  | участники опрелены | да | да | нет |
| 37 | 1.1.5.2 | Разработка программа видеоконференции | 3d | 2012-03-12 A | 2012-03-14 A | 36 | 100% |  |  |  | start no earlier than 2012-03-12 |  | разработана | да | да | нет |
| 38 | 1.1.5.3 | Проведение видеоконференции | 1d | 2012-03-15 A | 2012-03-15 A | 37 | 100% |  |  |  |  |  | проведено | да | да | нет |
| 39 | 1.1.6 | **Продвижение и пропаганда НХП в СМИ** | 181d | 2012-03-26 A | 2012-11-30 A |  | 100% |  |  |  |  | ܁) | количество материалов |  |  |  |
| 40 | 1.1.6.1 | Подготовка информационных материалов | 45d | 2012-03-26 A | 2012-11-16 A |  | 100% |  |  |  | start no earlier than 2012-03-26 |  | информация подготовлена | да | да | нет |
| 41 | 1.1.6.2 | Определение СМИ | 27d | 2012-04-09 A | 2012-11-13 A |  | 100% |  |  |  | start no earlier than 2012-04-09 |  | определен | да | да | нет |
| 42 | 1.1.6.3 | **Заключение договора выхода материалови их выпуск** | 170d | 2012-04-10 A | 2012-11-30 A |  | 100% |  |  |  |  | ܁) | договор заключен | да |  | нет |
| 43 | 1.1.6.3.1 | 1Выпускматериалов | 14d | 2012-04-10 A | 2012-04-27 A |  | 100% |  |  |  | finish no earlier than 2012-04-27 |  | издано | да | да | нет |
| 44 | 1.1.6.3.2 | 2Выпуск материалов | 14d | 2012-08-13 A | 2012-08-30 A |  | 100% |  |  |  | finish no earlier than 2012-08-30 |  | издано | да | да | нет |
| 45 | 1.1.6.3.3 | 3Выпуск материалов | 13d | 2012-11-14 A | 2012-11-30 A |  | 100% |  |  |  | finish no earlier than 2012-11-30 |  | издано | да | да | нет |
| 46 | 1.1.7 | **Задача 2. Обеспечение финансовой государственной поддержки развития отрасли НХП Ярославской области** | 248d | 2012-01-20 A | 2012-12-31 |  | 66% | 84.63d | 0d |  |  | ܁) | доля организаций и ИП, получивших поддержку | 10 |  |  |
| 47 | 1.1.7.1 | **Предоставление организациям и ИП, занятым в сфере НХП ЯО, субсидий на возмещение части затрат на уплату процентов по кредитам, полученным в российских кредитных организациях для закупки сырья, материалов, оборудования и запасных частей к нему** | 248d | 2012-01-20 | 2012-12-31 |  |  |  | 0d |  |  | ܁) | количество организаций и ИП получивших поддержку |  |  |  |
| 48 | 1.1.7.1.1 | **Прием и регистрация заявок на получение субсидии** | 190d | 2012-01-20 | 2012-10-10 |  |  |  | 0d |  |  | ܁) | предварительная экспертиза проведена | да | нет | нет |
| 49 | 1.1.7.1.1.1 | Прием и регистрация заявок на получение субсидии 1 | 8d | 2012-01-20 | 2012-01-31 |  |  |  | 178d | 0d | finish no earlier than 2012-01-31 |  |  | да | нет | нет |
| 50 | 1.1.7.1.1.2 | Прием и регистрация заявок на получение субсидии 2 | 7d | 2012-04-02 | 2012-04-10 |  |  |  | 129d | 0d | finish no earlier than 2012-04-10 |  |  | да | нет | нет |
| 51 | 1.1.7.1.1.3 | Прием и регистрация заявок на получение субсидии 3 | 7d | 2012-07-02 | 2012-07-10 |  |  |  | 64d | 0d | finish no earlier than 2012-07-10 |  |  | да | нет | нет |
| 52 | 1.1.7.1.1.4 | Прием и регистрация заявок на получение субсидии 4 | 8d | 2012-10-01 | 2012-10-10 |  |  |  | 0d |  | finish no earlier than 2012-10-10 |  |  | да | нет | нет |

| ID | WBS | Task | Duration | Start | Finish | Predecessors | Total slack | Free slack | Constraint | Text1 | Text3 | Text5 | Text6 | Text7 |
| --- | --- | --- | --- | --- | --- | --- | --- | --- | --- | --- | --- | --- | --- | --- |
| 53 | 1.1.7.1.2 | **Проведение предварительной экспертизы документов заявителя** | 185d | 2012-02-01 | 2012-10-15 |  | 0d |  |  | ܁) | предварительная экспертиза проведена | да | нет | нет |
| 54 | 1.1.7.1.2.1 | Проведение предварительной экспертизы документов заявителя 1 | 5d | 2012-02-01 | 2012-02-07 | 49 | 178d | 0d | finish no earlier than 2012-02-07 |  |  | да | нет | нет |
| 55 | 1.1.7.1.2.2 | Проведение предварительной экспертизы документов заявителя 2 | 3d | 2012-04-11 | 2012-04-13 | 50 | 129d | 0d | finish no earlier than 2012-04-13 |  |  | да | нет | нет |
| 56 | 1.1.7.1.2.3 | Проведение предварительной экспертизы документов заявителя 3 | 3d | 2012-07-11 | 2012-07-13 | 51 | 64d | 0d | finish no earlier than 2012-07-13 |  |  | да | нет | нет |
| 57 | 1.1.7.1.2.4 | Проведение предварительной экспертизы документов заявителя 4 | 3d | 2012-10-11 | 2012-10-15 | 52 | 0d |  | finish no earlier than 2012-10-15 |  |  | да | нет | нет |
| 58 | 1.1.7.1.3 | **Передача комплекта документов заявителя в УПК Правительства области** | 183d | 2012-02-08 | 2012-10-18 |  | 0d |  |  |  | комплект документов направлен в УПК | да | нет | нет |
| 59 | 1.1.7.1.3.1 | Передача комплекта документов заявителя в УПК Правительства области на экспертизу 1 | 3d | 2012-02-08 | 2012-02-10 | 54 | 178d | 0d | finish no earlier than 2012-02-10 |  |  | да | нет | нет |
| 60 | 1.1.7.1.3.2 | Передача комплекта документов заявителя в УПК Правительства области на экспертизу 2 | 3d | 2012-04-16 | 2012-04-18 | 55 | 129d | 0d | finish no earlier than 2012-04-18 |  |  | да | нет | нет |
| 61 | 1.1.7.1.3.3 | Передача комплекта документов заявителя в УПК Правительства области на экспертизу 3 | 3d | 2012-07-16 | 2012-07-18 | 56 | 64d | 0d | finish no earlier than 2012-07-18 |  |  | да | нет | нет |
| 62 | 1.1.7.1.3.4 | Передача комплекта документов заявителя в УПК Правительства области на экспертизу 4 | 3d | 2012-10-16 | 2012-10-18 | 57 | 0d |  | finish no earlier than 2012-10-18 |  |  | да | нет | нет |
| 63 | 1.1.7.1.4 | **Подготовка заключений о деятельности заявителя и направление их в ДПП ЯО** | 190d | 2012-02-13 | 2012-11-01 |  | 0d |  |  | ܁) | подготовлено заключение о деловой репутации заявителя | да | нет | нет |
| 64 | 1.1.7.1.4.1 | Подготовка заключений о деятельности заявителя и его деловой репутации, и направление их в ДПП ЯО 1 | 10d | 2012-02-13 | 2012-02-24 | 59 | 178d | 0d | finish no earlier than 2012-02-24 |  |  | да | нет | нет |
| 65 | 1.1.7.1.4.2 | Подготовка заключений о деятельности заявителя и его деловой репутации, и направление их в ДПП ЯО 2 | 10d | 2012-04-19 | 2012-05-02 | 60 | 129d | 0d | finish no earlier than 2012-05-02 |  |  | да | нет | нет |
| 66 | 1.1.7.1.4.3 | Подготовка заключений о деятельности заявителя и его деловой репутации, и направление их в ДПП ЯО 3 | 10d | 2012-07-19 | 2012-08-01 | 61 | 64d | 1d | finish no earlier than 2012-08-01 |  |  | да | нет | нет |
| 67 | 1.1.7.1.4.4 | Подготовка заключений о деятельности заявителя и его деловой репутации, и направление их в ДПП ЯО 4 | 10d | 2012-10-19 | 2012-11-01 | 62 | 0d |  | finish no earlier than 2012-11-01 |  |  | да | нет | нет |
| 68 | 1.1.7.1.5 | **Подготовка материалов для вынесения заявок на рассмотрение комиссии** | 185d | 2012-02-27 | 2012-11-08 |  | 0d |  |  | ܁) | материалы подготовлены и вынесены на заседание комиссии | да | нет | нет |
| 69 | 1.1.7.1.5.1 | Подготовка материалов для вынесения заявок на рассмотрение комиссии 1 | 5d | 2012-02-27 | 2012-03-02 | 64 | 178d | 0d | finish no earlier than 2012-03-02 |  |  | да | нет | нет |
| 70 | 1.1.7.1.5.2 | Подготовка материалов для вынесения заявок на рассмотрение комиссии 2 | 6d | 2012-05-03 | 2012-05-10 | 65 | 129d | 0d | finish no earlier than 2012-05-10 |  |  | да | нет | нет |
| 71 | 1.1.7.1.5.3 | Подготовка материалов для вынесения заявок на рассмотрение комиссии 3 | 5d | 2012-08-03 | 2012-08-09 | 66 | 63d | 0d | finish no earlier than 2012-08-09 |  |  | да | нет | нет |
| 72 | 1.1.7.1.5.4 | Подготовка материалов для вынесения заявок на рассмотрение комиссии 4 | 5d | 2012-11-02 | 2012-11-08 | 67 | 0d |  | finish no earlier than 2012-11-08 |  |  | да | нет | нет |
| 73 | 1.1.7.1.6 | **Рассмотрение заявок на заседании комиссии** | 190d | 2012-03-05 | 2012-11-22 |  | 0d |  |  |  | принято решение о предоставлении /непредоставлении субсидии | да | нет | нет |
| 74 | 1.1.7.1.6.1 | Рассмотрение заявок на заседании комиссии 1 | 10d | 2012-03-05 | 2012-03-16 | 69 | 178d | 0d | finish no earlier than 2012-03-16 |  |  | да | нет | нет |
| 75 | 1.1.7.1.6.2 | Рассмотрение заявок на заседании комиссии 2 | 10d | 2012-05-11 | 2012-05-24 | 70 | 129d | 0d | finish no earlier than 2012-05-24 |  |  | да | нет | нет |
| 76 | 1.1.7.1.6.3 | Рассмотрение заявок на заседании комиссии 3 | 10d | 2012-08-10 | 2012-08-23 | 71 | 63d | 0d | finish no earlier than 2012-08-23 |  |  | да | нет | нет |
| 77 | 1.1.7.1.6.4 | Рассмотрение заявок на заседании комиссии 4 | 10d | 2012-11-09 | 2012-11-22 | 72 | 0d |  | finish no earlier than 2012-11-22 |  |  | да | нет | нет |

| ID | WBS | Task | Duration | Start | Finish | Predecessors | Complete | Remaining | Total slack | Free slack | Constraint | Text3 | Text5 | Text6 | Text7 | Text1 |
| --- | --- | --- | --- | --- | --- | --- | --- | --- | --- | --- | --- | --- | --- | --- | --- | --- |
| 78 | 1.1.7.1.7 | **Офрмление и размещение протокола заседания комиссии на официальном портале ОГВ ЯО** | 184d | 2012-03-19 | 2012-11-28 |  |  |  | 0d |  |  | протокол размещен | да | нет | нет |  |
| 79 | 1.1.7.1.7.1 | Оформление и размещение протокола заседания комиссии на официальном портале ОГВ ЯО 1 | 4d | 2012-03-19 | 2012-03-22 | 74 |  |  | 178d | 0d | start no earlier than 2012-03-19 |  | да | нет | нет |  |
| 80 | 1.1.7.1.7.2 | Оформление и размещение протокола заседания комиссии на официальном портале ОГВ ЯО 2 | 4d | 2012-05-25 | 2012-05-30 | 75 |  |  | 129d | 0d | start no earlier than 2012-05-25 |  | да | нет | нет |  |
| 81 | 1.1.7.1.7.3 | Оформление и размещение протокола заседания комиссии на официальном портале ОГВ ЯО 3 | 4d | 2012-08-24 | 2012-08-29 | 76 |  |  | 63d | 0d | start no earlier than 2012-08-24 |  | да | нет | нет |  |
| 82 | 1.1.7.1.7.4 | Оформление и размещение протокола заседания комиссии на официальном портале ОГВ ЯО 4 | 4d | 2012-11-23 | 2012-11-28 | 77 |  |  | 0d |  | start no earlier than 2012-11-23 |  | да | нет | нет |  |
| 83 | 1.1.7.1.8 | **Подготовка проекта соглашения о предоставлении субсидии и направление его заявителю** | 185d | 2012-03-23 | 2012-12-05 |  |  |  | 0d |  |  | проект соглашения подготовлен и направлен заявителю | да | нет | нет |  |
| 84 | 1.1.7.1.8.1 | Подготовка проекта соглашения о предоставлении субсидии и направление его заявителю 1 | 5d | 2012-03-23 | 2012-03-29 | 79 |  |  | 178d | 0d | start no earlier than 2012-03-23 |  | да | нет | нет |  |
| 85 | 1.1.7.1.8.2 | Подготовка проекта соглашения о предоставлении субсидии и направление его заявителю 2 | 5d | 2012-05-31 | 2012-06-05 | 80 |  |  | 129d | 0d | start no earlier than 2012-05-31 |  | да | нет | нет |  |
| 86 | 1.1.7.1.8.3 | Подготовка проекта соглашения о предоставлении субсидии и направление его заявителю 3 | 5d | 2012-08-30 | 2012-09-05 | 81 |  |  | 63d | 0d | start no earlier than 2012-08-30 |  | да | нет | нет |  |
| 87 | 1.1.7.1.8.4 | Подготовка проекта соглашения о предоставлении субсидии и направление его заявителю 4 | 5d | 2012-11-29 | 2012-12-05 | 82 |  |  | 0d |  | start no earlier than 2012-11-29 |  | да | нет | нет |  |
| 88 | 1.1.7.1.9 | **Получение подписанного заявителем соглашения о предоставлении субсидии** | 190d | 2012-03-30 | 2012-12-19 |  |  |  | 0d |  |  | подписанное соглашение получено | да | нет | нет |  |
| 89 | 1.1.7.1.9.1 | Получение подписанного заявителем соглашения о предоставлении субсидии 1 | 10d | 2012-03-30 | 2012-04-12 | 84 |  |  | 178d | 0d | start no earlier than 2012-03-30 |  | да | нет | нет |  |
| 90 | 1.1.7.1.9.2 | Получение подписанного заявителем соглашения о предоставлении субсидии 2 | 10d | 2012-06-06 | 2012-06-19 | 85 |  |  | 129d | 0d |  |  | да | нет | нет |  |
| 91 | 1.1.7.1.9.3 | Получение подписанного заявителем соглашения о предоставлении субсидии 3 | 10d | 2012-09-06 | 2012-09-19 | 86 |  |  | 63d | 0d | start no earlier than 2012-09-06 |  | да | нет | нет |  |
| 92 | 1.1.7.1.9.4 | Получение подписанного заявителем соглашения о предоставлении субсидии 4 | 10d | 2012-12-06 | 2012-12-19 | 87 |  |  | 0d |  | start no earlier than 2012-12-06 |  | да | нет | нет |  |
| 93 | 1.1.7.1.10 | **Заключение соглашения и предоставление субсидии заявителю** | 188d | 2012-04-13 | 2012-12-31 |  |  |  | 0d |  |  | субсидия предоставлена | да | нет | нет |  |
| 94 | 1.1.7.1.10.1 | Заключение соглашения и предоставление субсидии заявителю 1 | 10d | 2012-04-13 | 2012-04-26 | 89 |  |  | 178d |  | start no earlier than 2012-04-13 |  | да | нет | нет |  |
| 95 | 1.1.7.1.10.2 | Заключение соглашения и предоставление субсидии заявителю 2 | 10d | 2012-06-20 | 2012-07-03 | 90 |  |  | 129d |  | start no earlier than 2012-06-20 |  | да | нет | нет |  |
| 96 | 1.1.7.1.10.3 | Заключение соглашения и предоставление субсидии заявителю 3 | 10d | 2012-09-20 | 2012-10-03 | 91 |  |  | 63d |  | start no earlier than 2012-09-20 |  | да | нет | нет |  |
| 97 | 1.1.7.1.10.4 | Заключение соглашения и предоставление субсидии заявителю 4 | 8d | 2012-12-20 | 2012-12-31 | 92 |  |  | 0d |  | start no earlier than 2012-12-20 |  | да | нет | нет |  |
| 98 | 1.1.7.2 | **Предоставление организациям и индивидуальным предпринимателям, занятым в сфере НХП Ярославской области, субсидий на возмещение части произведенных затрат на потребленную электрическую энергию** | 248d | 2012-01-20 A | 2012-12-31 |  | 98% | 5.9d | 0d |  |  | количество организаций и ИП получивших поддержку |  |  |  | ܁) |
| 99 | 1.1.7.2.1 | **Прием и регистрация заявок на получение субсидии** | 190d | 2012-01-20 A | 2012-10-10 A |  | 100% |  |  |  |  | предварительная экспертиза проведена | да | да | нет | ܁) |
| 100 | 1.1.7.2.1.1 | Прием и регистрация заявок на получение субсидии 1 | 8d | 2012-01-20 A | 2012-01-31 A |  | 100% |  |  |  | start no earlier than 2012-01-20 |  | да | да | нет |  |
| 101 | 1.1.7.2.1.2 | Прием и регистрация заявок на получение субсидии 2 | 7d | 2012-04-02 A | 2012-04-10 A |  | 100% |  |  |  | start no earlier than 2012-04-02 |  | да | да | нет |  |
| 102 | 1.1.7.2.1.3 | Прием и регистрация заявок на получение субсидии 3 | 7d | 2012-07-02 A | 2012-07-10 A |  | 100% |  |  |  | start no earlier than 2012-07-02 |  | да | да | нет |  |
| 103 | 1.1.7.2.1.4 | Прием и регистрация заявок на получение субсидии 4 | 8d | 2012-10-01 A | 2012-10-10 A |  | 100% |  |  |  | start no earlier than 2012-10-01 |  | да | да | нет |  |

| ID | WBS | Task | Duration | Start | Finish | Predecessors | Complete | Constraint | Text1 | Text3 | Text5 | Text6 | Text7 |
| --- | --- | --- | --- | --- | --- | --- | --- | --- | --- | --- | --- | --- | --- |
| 104 | 1.1.7.2.2 | **Проведение предварительной экспертизы документов заявителя** | 185d | 2012-02-01 A | 2012-10-15 A |  | 100% |  | ܁) | предварительная экспертиза проведена | да | да | нет |
| 105 | 1.1.7.2.2.1 | Проведение предварительной экспертизы документов заявителя 1 | 5d | 2012-02-01 A | 2012-02-07 A | 100 | 100% | start no earlier than 2012-02-01 |  |  | да | да | нет |
| 106 | 1.1.7.2.2.2 | Проведение предварительной экспертизы документов заявителя 2 | 3d | 2012-04-11 A | 2012-04-13 A | 101 | 100% | start no earlier than 2012-04-11 |  |  | да | да | нет |
| 107 | 1.1.7.2.2.3 | Проведение предварительной экспертизы документов заявителя 3 | 3d | 2012-07-11 A | 2012-07-13 A | 102 | 100% | start no earlier than 2012-07-11 |  |  | да | да | нет |
| 108 | 1.1.7.2.2.4 | Проведение предварительной экспертизы документов заявителя 4 | 3d | 2012-10-11 A | 2012-10-15 A | 103 | 100% | start no earlier than 2012-10-11 |  |  | да | да | нет |
| 109 | 1.1.7.2.3 | **Передача комплекта документов заявителя в УПК Правительства области** | 183d | 2012-02-08 A | 2012-10-18 A |  | 100% |  | ܁) | комплект документов направлен в УПК | да | да | нет |
| 110 | 1.1.7.2.3.1 | Передача комплекта документов заявителя в УПК Правительства области на экспертизу 1 | 3d | 2012-02-08 A | 2012-02-10 A | 105 | 100% | start no earlier than 2012-02-08 |  |  | да | да | нет |
| 111 | 1.1.7.2.3.2 | Передача комплекта документов заявителя в УПК Правительства области на экспертизу 2 | 3d | 2012-04-16 A | 2012-04-18 A | 106 | 100% | start no earlier than 2012-04-16 |  |  | да | да | нет |
| 112 | 1.1.7.2.3.3 | Передача комплекта документов заявителя в УПК Правительства области на экспертизу 3 | 3d | 2012-07-16 A | 2012-07-18 A | 107 | 100% | start no earlier than 2012-07-16 |  |  | да | да | нет |
| 113 | 1.1.7.2.3.4 | Передача комплекта документов заявителя в УПК Правительства области на экспертизу 4 | 3d | 2012-10-16 A | 2012-10-18 A | 108 | 100% | start no earlier than 2012-10-16 |  |  | да | да | нет |
| 114 | 1.1.7.2.4 | **Подготовка заключений о деятельности заявителя и направление их в ДПП ЯО** | 190d | 2012-02-13 A | 2012-11-01 A |  | 100% |  | ܁) | подготовлено заключение о деловой репутации заявителя | да | да | нет |
| 115 | 1.1.7.2.4.1 | Подготовка заключений о деятельности заявителя и его деловой репутации, и направление их в ДПП ЯО 1 | 10d | 2012-02-13 A | 2012-02-24 A | 110 | 100% | start no earlier than 2012-02-13 |  |  | да | да | нет |
| 116 | 1.1.7.2.4.2 | Подготовка заключений о деятельности заявителя и его деловой репутации, и направление их в ДПП ЯО 2 | 10d | 2012-04-19 A | 2012-05-02 A | 111 | 100% | start no earlier than 2012-04-19 |  |  | да | да | нет |
| 117 | 1.1.7.2.4.3 | Подготовка заключений о деятельности заявителя и его деловой репутации, и направление их в ДПП ЯО 3 | 10d | 2012-07-19 A | 2012-08-01 A | 112 | 100% | start no earlier than 2012-07-19 |  |  | да | да | нет |
| 118 | 1.1.7.2.4.4 | Подготовка заключений о деятельности заявителя и его деловой репутации, и направление их в ДПП ЯО 4 | 10d | 2012-10-19 A | 2012-11-01 A | 113 | 100% | start no earlier than 2012-10-19 |  |  | да | да | нет |
| 119 | 1.1.7.2.5 | **Подготовка материалов для вынесения заявок на рассмотрение комиссии** | 185d | 2012-02-27 A | 2012-11-08 A |  | 100% |  | ܁) | материалы подготовлены и вынесены на заседание комиссии | да | да | нет |
| 120 | 1.1.7.2.5.1 | Подготовка материалов для вынесения заявок на рассмотрение комиссии 1 | 5d | 2012-02-27 A | 2012-03-02 A | 115 | 100% | start no earlier than 2012-02-27 |  |  | да | да | нет |
| 121 | 1.1.7.2.5.2 | Подготовка материалов для вынесения заявок на рассмотрение комиссии 2 | 6d | 2012-05-03 A | 2012-05-10 A | 116 | 100% | start no earlier than 2012-05-03 |  |  | да | да | нет |
| 122 | 1.1.7.2.5.3 | Подготовка материалов для вынесения заявок на рассмотрение комиссии 3 | 5d | 2012-08-03 A | 2012-08-09 A | 117 | 100% | start no earlier than 2012-08-03 |  |  | да | да | нет |
| 123 | 1.1.7.2.5.4 | Подготовка материалов для вынесения заявок на рассмотрение комиссии 4 | 5d | 2012-11-02 A | 2012-11-08 A | 118 | 100% | start no earlier than 2012-11-02 |  |  | да | да | нет |
| 124 | 1.1.7.2.6 | **Рассмотрение заявок на заседании комиссии** | 190d | 2012-03-05 A | 2012-11-22 A |  | 100% |  | ܁) | принято решение о предоставлении /непредоставлении субсидии | да | да | нет |
| 125 | 1.1.7.2.6.1 | Рассмотрение заявок на заседании комиссии 1 | 10d | 2012-03-05 A | 2012-03-16 A | 120 | 100% | start no earlier than 2012-03-05 |  |  | да | да | нет |
| 126 | 1.1.7.2.6.2 | Рассмотрение заявок на заседании комиссии 2 | 10d | 2012-05-11 A | 2012-05-24 A | 121 | 100% | start no earlier than 2012-05-11 |  |  | да | да | нет |
| 127 | 1.1.7.2.6.3 | Рассмотрение заявок на заседании комиссии 3 | 10d | 2012-08-10 A | 2012-08-23 A | 122 | 100% | start no earlier than 2012-08-10 |  |  | да | да | нет |
| 128 | 1.1.7.2.6.4 | Рассмотрение заявок на заседании комиссии 4 | 10d | 2012-11-09 A | 2012-11-22 A | 123 | 100% | start no earlier than 2012-11-09 |  |  | да | да | нет |

| ID | WBS | Task | Duration | Start | Finish | Predecessors | Complete | Remaining | Total slack | Constraint | Text1 | Text3 | Text5 | Text6 | Text7 |
| --- | --- | --- | --- | --- | --- | --- | --- | --- | --- | --- | --- | --- | --- | --- | --- |
| 129 | 1.1.7.2.7 | **Офрмление и размещение протокола заседания комиссии на официальном портале ОГВ ЯО** | 184d | 2012-03-19 A | 2012-11-28 A |  | 100% |  |  |  | ܁) | протокол размещен | да | да | нет |
| 130 | 1.1.7.2.7.1 | Оформление и размещение протокола заседания комиссии на официальном портале ОГВ ЯО 1 | 4d | 2012-03-19 A | 2012-03-22 A | 125 | 100% |  |  | start no earlier than 2012-03-19 |  |  | да | да | нет |
| 131 | 1.1.7.2.7.2 | Оформление и размещение протокола заседания комиссии на официальном портале ОГВ ЯО 2 | 4d | 2012-05-25 A | 2012-05-30 A | 126 | 100% |  |  | start no earlier than 2012-05-25 |  |  | да | да | нет |
| 132 | 1.1.7.2.7.3 | Оформление и размещение протокола заседания комиссии на официальном портале ОГВ ЯО 3 | 4d | 2012-08-24 A | 2012-08-29 A | 127 | 100% |  |  | start no earlier than 2012-08-24 |  |  | да | да | нет |
| 133 | 1.1.7.2.7.4 | Оформление и размещение протокола заседания комиссии на официальном портале ОГВ ЯО 4 | 4d | 2012-11-23 A | 2012-11-28 A | 128 | 100% |  |  | start no earlier than 2012-11-23 |  |  | да | да | нет |
| 134 | 1.1.7.2.8 | **Подготовка проекта соглашения о предоставлении субсидии и направление его заявителю** | 185d | 2012-03-23 A | 2012-12-05 A |  | 100% |  |  |  | ܁) | проект соглашения подготовлен и направлен заявителю | да | да | нет |
| 135 | 1.1.7.2.8.1 | Подготовка проекта соглашения о предоставлении субсидии и направление его заявителю 1 | 5d | 2012-03-23 A | 2012-03-29 A | 130 | 100% |  |  | start no earlier than 2012-03-23 |  |  | да | да | нет |
| 136 | 1.1.7.2.8.2 | Подготовка проекта соглашения о предоставлении субсидии и направление его заявителю 2 | 5d | 2012-05-31 A | 2012-06-05 A | 131 | 100% |  |  | start no earlier than 2012-05-31 |  |  | да | да | нет |
| 137 | 1.1.7.2.8.3 | Подготовка проекта соглашения о предоставлении субсидии и направление его заявителю 3 | 5d | 2012-08-30 A | 2012-09-05 A | 132 | 100% |  |  | start no earlier than 2012-08-30 |  |  | да | да | нет |
| 138 | 1.1.7.2.8.4 | Подготовка проекта соглашения о предоставлении субсидии и направление его заявителю 4 | 5d | 2012-11-29 A | 2012-12-05 A | 133 | 100% |  |  | start no earlier than 2012-11-29 |  |  | да | да | нет |
| 139 | 1.1.7.2.9 | **Получение подписанного заявителем соглашения о предоставлении субсидии** | 190d | 2012-03-30 A | 2012-12-19 |  | 84% | 30.63d | 8d |  | ܁) | подписанное соглашение получено | да | да | нет |
| 140 | 1.1.7.2.9.1 | Получение подписанного заявителем соглашения о предоставлении субсидии 1 | 10d | 2012-03-30 A | 2012-04-12 A | 135 | 100% |  |  | start no earlier than 2012-03-30 |  |  | да | да | нет |
| 141 | 1.1.7.2.9.2 | Получение подписанного заявителем соглашения о предоставлении субсидии 2 | 10d | 2012-06-06 A | 2012-06-19 A | 136 | 100% |  |  | start no earlier than 2012-06-06 |  |  | да | да | нет |
| 142 | 1.1.7.2.9.3 | Получение подписанного заявителем соглашения о предоставлении субсидии 3 | 10d | 2012-09-06 A | 2012-09-19 A | 137 | 100% |  |  | start no earlier than 2012-09-06 |  |  | да | да | нет |
| 143 | 1.1.7.2.9.4 | Получение подписанного заявителем соглашения о предоставлении субсидии 4 | 10d | 2012-12-06 A | 2012-12-19 | 138 | 36% | 6.45d | 8d | start no earlier than 2012-12-06 |  |  | да | да | нет |
| 144 | 1.1.7.2.10 | **Заключение соглашения и предоставление субсидии заявителю** | 188d | 2012-04-13 A | 2012-12-31 A |  | 100% |  |  |  | ܁) | субсидия предоставлена | да | да | нет |
| 145 | 1.1.7.2.10.1 | Заключение соглашения и предоставление субсидии заявителю 1 | 10d | 2012-04-13 A | 2012-04-26 A | 140 | 100% |  |  | start no earlier than 2012-04-13 |  |  | да | да | нет |
| 146 | 1.1.7.2.10.2 | Заключение соглашения и предоставление субсидии заявителю 2 | 10d | 2012-06-20 A | 2012-07-03 A | 141 | 100% |  |  | start no earlier than 2012-06-20 |  |  | да | да | нет |
| 147 | 1.1.7.2.10.3 | Заключение соглашения и предоставление субсидии заявителю 3 | 10d | 2012-09-20 A | 2012-10-03 A | 142 | 100% |  |  | start no earlier than 2012-09-20 |  |  | да | да | нет |
| 148 | 1.1.7.2.10.4 | Заключение соглашения и предоставление субсидии заявителю 4 | 8d | 2012-12-20 A | 2012-12-31 A | 143 | 100% |  |  | start no earlier than 2012-12-20 |  |  | да | да | нет |
| 149 | 1.1.7.3 | **Предоставление организациям и индивидуальным предпринимателям, занятым в сфере НХП Ярославской области, субсидий на возмещение части произведенных затрат на потребленный природный газ** | 248d | 2012-01-20 A | 2012-12-31 A |  | 100% |  |  |  | ܁) | количество организаций и ИП получивших поддержку |  |  |  |
| 150 | 1.1.7.3.1 | **Прием и регистрация заявок на получение субсидии** | 190d | 2012-01-20 A | 2012-10-10 A |  | 100% |  |  |  | ܁) | предварительная экспертиза проведена | да | да | нет |
| 151 | 1.1.7.3.1.1 | Прием и регистрация заявок на получение субсидии 1 | 8d | 2012-01-20 A | 2012-01-31 A |  | 100% |  |  | start no earlier than 2012-01-20 |  |  | да | да | нет |
| 152 | 1.1.7.3.1.2 | Прием и регистрация заявок на получение субсидии 2 | 7d | 2012-04-02 A | 2012-04-10 A |  | 100% |  |  | start no earlier than 2012-04-02 |  |  | да | да | нет |
| 153 | 1.1.7.3.1.3 | Прием и регистрация заявок на получение субсидии 3 | 7d | 2012-07-02 A | 2012-07-10 A |  | 100% |  |  | start no earlier than 2012-07-02 |  |  | да | да | нет |
| 154 | 1.1.7.3.1.4 | Прием и регистрация заявок на получение субсидии 4 | 8d | 2012-10-01 A | 2012-10-10 A |  | 100% |  |  | start no earlier than 2012-10-01 |  |  | да | да | нет |

| ID | WBS | Task | Duration | Start | Finish | Predecessors | Complete | Constraint | Text1 | Text3 | Text5 | Text6 | Text7 |
| --- | --- | --- | --- | --- | --- | --- | --- | --- | --- | --- | --- | --- | --- |
| 155 | 1.1.7.3.2 | **Проведение предварительной экспертизы документов заявителя** | 185d | 2012-02-01 A | 2012-10-15 A |  | 100% |  | ܁) | предварительная экспертиза проведена | да | да | нет |
| 156 | 1.1.7.3.2.1 | Проведение предварительной экспертизы документов заявителя 1 | 5d | 2012-02-01 A | 2012-02-07 A | 151 | 100% | start no earlier than 2012-01-02 |  |  | да | да | нет |
| 157 | 1.1.7.3.2.2 | Проведение предварительной экспертизы документов заявителя 2 | 3d | 2012-04-11 A | 2012-04-13 A | 152 | 100% | start no earlier than 2012-02-02 |  |  | да | да | нет |
| 158 | 1.1.7.3.2.3 | Проведение предварительной экспертизы документов заявителя 3 | 3d | 2012-07-11 A | 2012-07-13 A | 153 | 100% | start no earlier than 2012-03-02 |  |  | да | да | нет |
| 159 | 1.1.7.3.2.4 | Проведение предварительной экспертизы документов заявителя 4 | 3d | 2012-10-11 A | 2012-10-15 A | 154 | 100% | start no earlier than 2012-04-02 |  |  | да | да | нет |
| 160 | 1.1.7.3.3 | **Передача комплекта документов заявителя в УПК Правительства области** | 183d | 2012-02-08 A | 2012-10-18 A |  | 100% |  | ܁) | комплект документов направлен в УПК | да | да | нет |
| 161 | 1.1.7.3.3.1 | Передача комплекта документов заявителя в УПК Правительства области на экспертизу 1 | 3d | 2012-02-08 A | 2012-02-10 A | 156 | 100% | start no earlier than 2012-01-02 |  |  | да | да | нет |
| 162 | 1.1.7.3.3.2 | Передача комплекта документов заявителя в УПК Правительства области на экспертизу 2 | 3d | 2012-04-16 A | 2012-04-18 A | 157 | 100% | start no earlier than 2012-02-02 |  |  | да | да | нет |
| 163 | 1.1.7.3.3.3 | Передача комплекта документов заявителя в УПК Правительства области на экспертизу 3 | 3d | 2012-07-16 A | 2012-07-18 A | 158 | 100% | start no earlier than 2012-03-02 |  |  | да | да | нет |
| 164 | 1.1.7.3.3.4 | Передача комплекта документов заявителя в УПК Правительства области на экспертизу 4 | 3d | 2012-10-16 A | 2012-10-18 A | 159 | 100% | start no earlier than 2012-04-02 |  |  | да | да | нет |
| 165 | 1.1.7.3.4 | **Подготовка заключений о деятельности заявителя и направление их в ДПП ЯО** | 190d | 2012-02-13 A | 2012-11-01 A |  | 100% |  | ܁) | подготовлено заключение о деловой репутации заявителя | да | да | нет |
| 166 | 1.1.7.3.4.1 | Подготовка заключений о деятельности заявителя и его деловой репутации, и направление их в ДПП ЯО 1 | 10d | 2012-02-13 A | 2012-02-24 A | 161 | 100% | start no earlier than 2012-01-02 |  |  | да | да | нет |
| 167 | 1.1.7.3.4.2 | Подготовка заключений о деятельности заявителя и его деловой репутации, и направление их в ДПП ЯО 2 | 10d | 2012-04-19 A | 2012-05-02 A | 162 | 100% | start no earlier than 2012-02-02 |  |  | да | да | нет |
| 168 | 1.1.7.3.4.3 | Подготовка заключений о деятельности заявителя и его деловой репутации, и направление их в ДПП ЯО 3 | 10d | 2012-07-19 A | 2012-08-01 A | 163 | 100% | start no earlier than 2012-03-02 |  |  | да | да | нет |
| 169 | 1.1.7.3.4.4 | Подготовка заключений о деятельности заявителя и его деловой репутации, и направление их в ДПП ЯО 4 | 10d | 2012-10-19 A | 2012-11-01 A | 164 | 100% | start no earlier than 2012-04-02 |  |  | да | да | нет |
| 170 | 1.1.7.3.5 | **Подготовка материалов для вынесения заявок на рассмотрение комиссии** | 185d | 2012-02-27 A | 2012-11-08 A |  | 100% |  | ܁) | материалы подготовлены и вынесены на заседание комиссии | да | да | нет |
| 171 | 1.1.7.3.5.1 | Подготовка материалов для вынесения заявок на рассмотрение комиссии 1 | 5d | 2012-02-27 A | 2012-03-02 A | 166 | 100% | start no earlier than 2012-01-02 |  |  | да | да | нет |
| 172 | 1.1.7.3.5.2 | Подготовка материалов для вынесения заявок на рассмотрение комиссии 2 | 6d | 2012-05-03 A | 2012-05-10 A | 167 | 100% | start no earlier than 2012-02-02 |  |  | да | да | нет |
| 173 | 1.1.7.3.5.3 | Подготовка материалов для вынесения заявок на рассмотрение комиссии 3 | 5d | 2012-08-02 A | 2012-08-08 A | 168 | 100% | start no earlier than 2012-03-02 |  |  | да | да | нет |
| 174 | 1.1.7.3.5.4 | Подготовка материалов для вынесения заявок на рассмотрение комиссии 4 | 5d | 2012-11-02 A | 2012-11-08 A | 169 | 100% | start no earlier than 2012-04-02 |  |  | да | да | нет |
| 175 | 1.1.7.3.6 | **Рассмотрение заявок на заседании комиссии** | 190d | 2012-03-05 A | 2012-11-22 A |  | 100% |  | ܁) | принято решение о предоставлении /непредоставлении субсидии | да | да | нет |
| 176 | 1.1.7.3.6.1 | Рассмотрение заявок на заседании комиссии 1 | 10d | 2012-03-05 A | 2012-03-16 A | 171 | 100% | start no earlier than 2012-01-02 |  |  | да | да | нет |
| 177 | 1.1.7.3.6.2 | Рассмотрение заявок на заседании комиссии 2 | 10d | 2012-05-11 A | 2012-05-24 A | 172 | 100% | start no earlier than 2012-02-02 |  |  | да | да | нет |
| 178 | 1.1.7.3.6.3 | Рассмотрение заявок на заседании комиссии 3 | 10d | 2012-08-09 A | 2012-08-22 A | 173 | 100% | start no earlier than 2012-03-02 |  |  | да | да | нет |
| 179 | 1.1.7.3.6.4 | Рассмотрение заявок на заседании комиссии 4 | 10d | 2012-11-09 A | 2012-11-22 A | 174 | 100% | start no earlier than 2012-04-02 |  |  | да | да | нет |

| ID | WBS | Task | Type | Duration | Start | Finish | Predecessors | Complete | Constraint | Text1 | Text5 | Text6 | Text7 |
| --- | --- | --- | --- | --- | --- | --- | --- | --- | --- | --- | --- | --- | --- |
| 180 | 1.1.7.3.7 | **Офрмление и размещение протокола заседания комиссии на официальном портале ОГВ ЯО** |  | 184d | 2012-03-19 A | 2012-11-28 A |  | 100% |  | ܁) | да | да | нет |
| 181 | 1.1.7.3.7.1 | Оформление и размещение протокола заседания комиссии на официальном портале ОГВ ЯО 1 |  | 4d | 2012-03-19 A | 2012-03-22 A | 176 | 100% | start no earlier than 2012-01-02 |  | да | да | нет |
| 182 | 1.1.7.3.7.2 | Оформление и размещение протокола заседания комиссии на официальном портале ОГВ ЯО 2 |  | 4d | 2012-05-25 A | 2012-05-30 A | 177 | 100% | start no earlier than 2012-02-02 |  | да | да | нет |
| 183 | 1.1.7.3.7.3 | Оформление и размещение протокола заседания комиссии на официальном портале ОГВ ЯО 3 |  | 4d | 2012-08-23 A | 2012-08-28 A | 178 | 100% | start no earlier than 2012-03-02 |  | да | да | нет |
| 184 | 1.1.7.3.7.4 | Оформление и размещение протокола заседания комиссии на официальном портале ОГВ ЯО 4 |  | 4d | 2012-11-23 A | 2012-11-28 A | 179 | 100% | start no earlier than 2012-04-02 |  | да | да | нет |
| 185 | 1.1.7.3.8 | **Подготовка проекта соглашения о предоставлении субсидии и направление его заявителю** |  | 185d | 2012-03-23 A | 2012-12-05 A |  | 100% |  | ܁) | да | да | нет |
| 186 | 1.1.7.3.8.1 | Подготовка проекта соглашения о предоставлении субсидии и направление его заявителю 1 |  | 5d | 2012-03-23 A | 2012-03-29 A | 181 | 100% | start no earlier than 2012-01-02 |  | да | да | нет |
| 187 | 1.1.7.3.8.2 | Подготовка проекта соглашения о предоставлении субсидии и направление его заявителю 2 |  | 5d | 2012-05-31 A | 2012-06-05 A | 182 | 100% | start no earlier than 2012-02-02 |  | да | да | нет |
| 188 | 1.1.7.3.8.3 | Подготовка проекта соглашения о предоставлении субсидии и направление его заявителю 3 |  | 5d | 2012-08-29 A | 2012-09-04 A | 183 | 100% | start no earlier than 2012-03-02 |  | да | да | нет |
| 189 | 1.1.7.3.8.4 | Подготовка проекта соглашения о предоставлении субсидии и направление его заявителю 4 |  | 5d | 2012-11-29 A | 2012-12-05 A | 184 | 100% | start no earlier than 2012-04-02 |  | да | да | нет |
| 190 | 1.1.7.3.9 | **Получение подписанного заявителем соглашения о предоставлении субсидии** |  | 190d | 2012-03-30 A | 2012-12-19 A |  | 100% |  | ܁) | да | да | нет |
| 191 | 1.1.7.3.9.1 | Получение подписанного заявителем соглашения о предоставлении субсидии 1 |  | 10d | 2012-03-30 A | 2012-04-12 A | 186 | 100% | start no earlier than 2012-01-02 |  | да | да | нет |
| 192 | 1.1.7.3.9.2 | Получение подписанного заявителем соглашения о предоставлении субсидии 2 |  | 10d | 2012-06-06 A | 2012-06-19 A | 187 | 100% | start no earlier than 2012-02-02 |  | да | да | нет |
| 193 | 1.1.7.3.9.3 | Получение подписанного заявителем соглашения о предоставлении субсидии 3 |  | 10d | 2012-09-05 A | 2012-09-18 A | 188 | 100% | start no earlier than 2012-03-02 |  | да | да | нет |
| 194 | 1.1.7.3.9.4 | Получение подписанного заявителем соглашения о предоставлении субсидии 4 |  | 10d | 2012-12-06 A | 2012-12-19 A | 189 | 100% | start no earlier than 2012-04-02 |  | да | да | нет |
| 195 | 1.1.7.3.10 | **Заключение соглашения и предоставление субсидии заявителю** |  | 188d | 2012-04-13 A | 2012-12-31 A |  | 100% |  | ܁) | да | да | нет |
| 196 | 1.1.7.3.10.1 | Заключение соглашения и предоставление субсидии заявителю 1 |  | 10d | 2012-04-13 A | 2012-04-26 A | 191 | 100% | start no earlier than 2012-01-02 |  | да | да | нет |
| 197 | 1.1.7.3.10.2 | Заключение соглашения и предоставление субсидии заявителю 2 |  | 10d | 2012-06-20 A | 2012-07-03 A | 192 | 100% | start no earlier than 2012-02-02 |  | да | да | нет |
| 198 | 1.1.7.3.10.3 | Заключение соглашения и предоставление субсидии заявителю 3 |  | 10d | 2012-09-19 A | 2012-10-02 A | 193 | 100% | start no earlier than 2012-03-02 |  | да | да | нет |
| 199 | 1.1.7.3.10.4 | Заключение соглашения и предоставление субсидии заявителю 4 |  | 8d | 2012-12-20 A | 2012-12-31 A | 194 | 100% | start no earlier than 2012-04-02 |  | да | да | нет |
| 200 | 1.2 | **Задача 3. Маркетинговая поддержка продвижения продукции, производимой организациями и индивидуальными предпринимателями в сфере НХП Ярославской области, на российский и международный рынки и стимулирование её сбыта** |  | 212d | 2012-02-24 A | 2012-12-14 A |  | 100% |  | ܁) | 160 | 295 |  |
| 201 | 1.2.1 | **Развитие механизма продвижения продукции организаций, индивидуальных предпринимателей и индивидуально работающих мастеров, занятых в сфере НХП, путем организации коллективных стендов на международных, межрегиональных, областных выставках и ярмарках** |  | 212d | 2012-02-24 A | 2012-12-14 A |  | 100% |  | ܁) | 40 | 295 |  |
| 202 | 1.2.1.1 | Участие в XII Выставке народных художественных промыслов России «Ладья - Весенняя фантазия 2012» г. Москва ЦВК «Экспоцентр», павильон №7 |  | 6d | 2012-02-24 A | 2012-03-02 A |  | 100% | start no earlier than 2012-02-24 | ܁) |  | 10 |  |
| 203 | 1.2.1.2 | Участие в Фестивале мастеров и художников России «Жар-Птица» ВВЦ, г.Москва, павильон № 69 |  | 3d | 2012-05-04 A | 2012-05-08 A |  | 100% | start no earlier than 2012-05-04 | ܁) | 10 | 27 |  |
| 204 | 1.2.1.3 | Организация «Дней народных художественных промыслов Ярославской области» в рамках Московского детского фестиваля искусств и ремесел «Мастера» г. Москва | milestone | 0d | 2012-06-03 A | 2012-06-03 A |  | 100% | start no earlier than 2012-06-03 | ܁) | 10 | 44 |  |
| 205 | 1.2.1.4 | Организация межрегионального фестиваля народных художественных промыслов и ремесел «Ярославский базар» г. Ярославль |  | 2d | 2012-10-26 A | 2012-10-29 A |  | 100% | start no earlier than 2012-10-26 | ܁) | 10 | 150 |  |
| 206 | 1.2.1.5 | Участие в XIII Всероссийской выставке – ярмарке народных художественных промыслов России «Ладья - Зимняя сказка 2012» г. Москва ЦВК «Экспоцентр» |  | 2d | 2012-12-13 A | 2012-12-14 A |  | 100% | start no earlier than 2012-12-13 | ܁) |  | 64 |  |

Notes:
- 180: Text3: протокол размещен
- 185: Text3: проект соглашения подготовлен и направлен заявителю
- 190: Text3: подписанное соглашение получено
- 195: Text3: субсидия предоставлена
- 200: Text3: количество участников мероприятий
- 201: Text3: количество организаций , ИП и индивидуально работающих мастеров участвующих в выставках и ярмарках
- 202: Text3: количество участвующих в выставке
- 203: Text3: количество участвующих в выставке
- 204: Text3: количество участвующих в выставке
- 205: Text3: количество участвующих в выставке
- 206: Text3: количество участвующих в выставке

| ID | WBS | Task | Duration | Start | Finish | Complete | Constraint | Text1 | Text3 | Text5 | Text6 |
| --- | --- | --- | --- | --- | --- | --- | --- | --- | --- | --- | --- |
| 207 | 1.3 | **Задача 4. Развитие кадрового обеспечения отрасли НХП** | 45d | 2012-10-01 A | 2012-11-30 A | 100% |  | ܁) | количество человек, прошедших обучение | 50 | 12 |
| 208 | 1.3.1 | Обучение мастеров с ограниченными физическими возможностями, занятых в сфере НХП | 22d | 2012-10-01 A | 2012-10-30 A | 100% | finish no earlier than 2012-10-30 | ܁) | количество человек | 15 |  |
| 209 | 1.3.2 | Организация обучения мастеров узкой специализации (мастеров шликерного литья, кружевоплетения и т.д.) | 22d | 2012-11-01 A | 2012-11-30 A | 100% | finish no earlier than 2012-11-30 | ܁) | количество человек | 35 |  |
